Schedule from MS Project, 2002-06-17 to 2003-02-28.

## Calendars

- Standard: Mon-Fri 08:00-12:00, 13:00-17:00; Sat-Sun off.

## Resources

| Resource |
| --- |
| Nelson |
| Williamson |
| Cole |
| Fogarty |
| Goranson |
| Ping |
| Brooks |
| Brown |
| Chranowski |
| Dahlgren |
| Fan |
| Heitzenroeder |
| Jun |
| Reiersen |
| Zatz |
| Rushinski |
| Morris |
| Irick |
| Ramakrishnan |
| Jones |

## Schedule

| ID | WBS | Task | Duration | Start | Finish | Predecessors | Total slack | Free slack | Constraint | Resources | Work |
| --- | --- | --- | --- | --- | --- | --- | --- | --- | --- | --- | --- |
| 1 | 1 | **Stellarator Core** | 184.44d | 2002-06-17 | 2003-02-28 |  | 0d |  |  |  | 5470.4h |
| 2 | 1.1 | **In-Vessel Components** | 40d | 2002-06-24 | 2002-08-16 |  | 138.44d |  |  |  | 240h |
| 3 | 1.1.1 | Modify PFC envelope to accommodate plasma, divertor, RF | 25d | 2002-06-24 | 2002-07-26 |  | 153.44d | 30.5d | start no earlier than 2002-06-24 | Cole [30%]; Nelson [30%] | 80h |
| 4 | 1.1.2 | Perform study of geom, current, voltage requirements for internal trim coils | 40d | 2002-06-24 | 2002-08-16 |  | 138.44d | 15.5d | start no earlier than 2002-06-24 | Brooks [50%] | 160h |
| 6 | 1.2 | **Vacuum Vessel** | 61.5d | 2002-06-17 | 2002-09-10 |  | 122.94d |  |  |  | 244h |
| 7 | 1.2.1 | Develop "B" spec (SRD) for vacuum vessel | 1d | 2002-07-08 | 2002-07-08 |  | 168.44d |  | start no earlier than 2002-07-08 |  |  |
| 8 | 1.2.2 | Perform structural analysis of a single period with ports blanked off (as per initial vacuum test) | 16.67d | 2002-06-17 | 2002-07-09 |  | 167.78d |  |  | Dahlgren [30%] | 40h |
| 9 | 1.2.3 | Adjust port heights to fit through door | 12.5d | 2002-08-22 | 2002-09-09 |  | 122.94d | 0d | start no earlier than 2002-08-22 | Cole [40%] | 40h |
| 10 | 1.2.4 | Evaluate PFC heat loads to vessel, re helium vs water cooling | 40d | 2002-06-24 | 2002-08-16 |  | 138.44d | 15.5d | start no earlier than 2002-06-24 | Goranson [50%] | 160h |
| 11 | 1.2.5 | **Initiate VV manufacturing R&D activities** | 1d | 2002-09-09 | 2002-09-10 | 3, 4, 9, 10 | 122.94d |  |  | Goranson [50%] | 4h |
| 12 | 1.2.5.1 | **Develop SOW** | 1d | 2002-09-09 | 2002-09-10 |  | 122.94d |  |  |  |  |
| 13 | 1.2.5.1.1 | Systematically review and disposition recommendations on manufacturing R&D activities proposed during mfg studies | 1d | 2002-09-09 | 2002-09-10 |  | 122.94d |  |  |  |  |
| 14 | 1.2.5.1.2 | Draft SOW for mfg R&D activities | 1d | 2002-09-09 | 2002-09-10 |  | 122.94d |  |  |  |  |
| 15 | 1.2.5.2 | **Develop draft product spec and Pro/E model** | 1d | 2002-09-09 | 2002-09-10 |  | 122.94d |  |  |  |  |
| 16 | 1.2.5.2.1 | Update Pro/E model of VV | 1d | 2002-09-09 | 2002-09-10 |  | 122.94d |  |  |  |  |
| 17 | 1.2.5.2.2 | Update draft product specification | 1d | 2002-09-09 | 2002-09-10 |  | 122.94d |  |  |  |  |
| 18 | 1.2.5.3 | **Develop RFP and selection criteria** | 1d | 2002-09-09 | 2002-09-10 |  | 122.94d |  |  |  |  |
| 19 | 1.2.5.3.1 | Resolve procurement strategy issues | 1d | 2002-09-09 | 2002-09-10 |  | 122.94d |  |  |  |  |
| 20 | 1.2.5.3.2 | Form SPEB | 1d | 2002-09-09 | 2002-09-10 |  | 122.94d |  |  |  |  |
| 21 | 1.2.5.3.3 | Develop selection criteria | 1d | 2002-09-09 | 2002-09-10 |  | 122.94d |  |  |  |  |
| 22 | 1.2.5.3.4 | Draft RFP | 1d | 2002-09-09 | 2002-09-10 |  | 122.94d |  |  |  |  |
| 23 | 1.2.5.4 | **Review and issue procurement package** | 1d | 2002-09-09 | 2002-09-10 |  | 122.94d |  |  |  |  |
| 24 | 1.2.5.4.1 | Announce plans for VV procurement, contact suppliers who have previously expressed interest | 1d | 2002-09-09 | 2002-09-10 |  | 122.94d |  |  |  |  |
| 25 | 1.2.5.4.2 | Review procurement package including updated Pro/E model, draft spec, SOW, RFP, and selection criteria | 1d | 2002-09-09 | 2002-09-10 |  | 122.94d |  |  |  |  |
| 26 | 1.2.5.4.3 | Release RFP, post on Web | 1d | 2002-09-09 | 2002-09-10 |  | 122.94d |  |  |  |  |

| ID | WBS | Task | Duration | Start | Finish | Predecessors | Total slack | Free slack | Constraint | Resources | Work |
| --- | --- | --- | --- | --- | --- | --- | --- | --- | --- | --- | --- |
| 27 | 1.2.5.5 | **Suppliers develop proposals** | 1d | 2002-09-09 | 2002-09-10 |  | 122.94d |  |  |  |  |
| 28 | 1.2.5.5.1 | Conduct pre-proposal meeting to review procurement with potential suppliers | 1d | 2002-09-09 | 2002-09-10 |  | 122.94d |  |  |  |  |
| 29 | 1.2.5.5.2 | Finalize procurement package based on supplier responses | 1d | 2002-09-09 | 2002-09-10 |  | 122.94d |  |  |  |  |
| 30 | 1.2.5.5.3 | Vendors complete responses | 1d | 2002-09-09 | 2002-09-10 |  | 122.94d |  |  |  |  |
| 31 | 1.2.5.6 | **Award contracts** | 1d | 2002-09-09 | 2002-09-10 |  | 122.94d |  |  |  |  |
| 32 | 1.2.5.6.1 | SPEB - evaluate responses, visit facilities, provide recommendations | 1d | 2002-09-09 | 2002-09-10 |  | 122.94d |  |  |  |  |
| 33 | 1.2.5.6.2 | Review selection process and results | 1d | 2002-09-09 | 2002-09-10 |  | 122.94d |  |  |  |  |
| 34 | 1.2.5.6.3 | Put contracts in place | 1d | 2002-09-09 | 2002-09-10 |  | 122.94d |  |  |  |  |
| 36 | 1.3 | **Conventional Coils** | 89d | 2002-06-24 | 2002-10-24 |  | 90.44d |  |  |  | 260h |
| 37 | 1.3.1 | Evaluate PF configuration changes (# turns, conductor size) | 41.67d | 2002-06-24 | 2002-08-20 |  | 137.78d |  | start no earlier than 2002-06-24 | Reiersen [30%] | 100h |
| 38 | 1.3.2 | Perform study of current, voltage requirements for external trim coils | 40d | 2002-08-30 | 2002-10-24 |  | 90.44d |  | start no earlier than 2002-08-30 | Brooks [50%] | 160h |
| 39 | 1.4 | **Modular Coils** | 111.33d | 2002-06-17 | 2002-11-19 |  | 73.11d |  |  |  | 2866.4h |
| 40 | 1.4.1 | **Design / Analysis** | 80d | 2002-06-17 | 2002-10-04 |  | 104.44d |  |  |  | 1860h |
| 41 | 1.4.1.1 | Develop draft "B" spec (SRD) for mod coils | 25d | 2002-06-17 | 2002-07-19 |  | 175.67d |  |  | Williamson [10%]; Nelson [10%] | 40h |
| 42 | 1.4.1.2 | **CDR Coil Geometry** | 80d | 2002-06-17 | 2002-10-04 |  | 104.44d |  |  |  | 1440h |
| 43 | 1.4.1.2.1 | Develop variable xsec tee using CDR geometry | 6.25d | 2002-06-24 | 2002-07-02 |  | 82.75d |  | start no earlier than 2002-06-24 | Williamson [40%] | 20h |
| 44 | 1.4.1.2.2 | Layout rods and clamps cooling concept -worst case 3-D | 20d | 2002-07-01 | 2002-07-26 |  | 112.78d | 0d | start no earlier than 2002-07-01 | Fogarty [50%]; Goranson [50%] | 160h |
| 45 | 1.4.1.2.3 | Specify shell flange and bolting details | 27.78d | 2002-06-24 | 2002-07-31 |  | 110d | 0d | start no earlier than 2002-06-24 | Dahlgren [30%]; Fan [30%]; Rushinski [30%] | 200h |
| 46 | 1.4.1.2.4 | Perform tolerance study for castings | 56.25d | 2002-06-24 | 2002-09-10 |  | 32.75d |  | start no earlier than 2002-06-24 | Nelson [30%]; Brooks [30%]; Chranowski [20%] | 180h |
| 47 | 1.4.1.2.5 | Update coil lead and clamp details (define crossover pockets, lead holes, stud locations) | 20d | 2002-07-29 | 2002-08-23 | 44 | 117.78d | 0d | start no earlier than 2002-07-22 | Fogarty [50%] | 80h |
| 48 | 1.4.1.2.6 | Perform thermal analysis of rods and clamps cooling concept | 25d | 2002-06-26 | 2002-07-30 |  | 152.44d |  | start no earlier than 2002-06-26 | Fan [60%] | 120h |
| 49 | 1.4.1.2.7 | Update stress analysis, optimize thickness and clamps arrangement | 25d | 2002-07-31 | 2002-09-03 |  | 127.44d |  | start no earlier than 2002-07-31 | Fan [90%]; Dahlgren [30%] | 240h |
| 50 | 1.4.1.2.8 | re-model shell surfaces in thin, overlap areas | 30d | 2002-06-17 | 2002-07-26 |  | 154.44d |  |  | Cole [50%] | 120h |
| 51 | 1.4.1.2.9 | Prepare drawings for RFP based on CDR geometry and updates | 23.53d | 2002-07-01 | 2002-08-01 |  | 84.25d | 0d | start no earlier than 2002-07-01 | Williamson [50%]; Cole [20%]; Ping [50%] | 200h |
| 52 | 1.4.1.2.10 | Develop modular coil design criteria | 75d | 2002-06-24 | 2002-10-04 |  | 104.44d |  | start no earlier than 2002-06-24 | Zatz [20%] | 120h |

| ID | WBS | Task | Type | Duration | Start | Finish | Predecessors | Total slack | Free slack | Constraint | Resources | Work |
| --- | --- | --- | --- | --- | --- | --- | --- | --- | --- | --- | --- | --- |
| 53 | 1.4.1.3 | **Updated Coil Geometry** |  | 65.89d | 2002-06-24 | 2002-09-23 |  | 113.55d |  |  |  | 380h |
| 54 | 1.4.1.3.1 | Prepare models, evaluate engineering parameters |  | 16.67d | 2002-06-24 | 2002-07-16 |  | 96.11d | 4.33d | start no earlier than 2002-06-24 | Williamson [30%] | 40h |
| 55 | 1.4.1.3.2 | Select final coil configuration | milestone | 0d | 2002-07-22 | 2002-07-22 | 54 | 121.08d | 7.53d | finish no earlier than 2002-07-22 |  |  |
| 56 | 1.4.1.3.3 | Update models and drawings for new coilset as basis for R&D |  | 37.36d | 2002-08-01 | 2002-09-23 | 55, 51 | 113.55d |  |  | Williamson [30%]; Cole [20%]; Ping [50%]; Jones [50%] | 340h |
| 57 | 1.4.2 | **R&D / Manufacture** |  | 111.33d | 2002-06-17 | 2002-11-19 |  | 73.11d |  |  |  | 1006.4h |
| 58 | 1.4.2.1 | Perform test coil winding, VPI, mechanical tests |  | 66.67d | 2002-06-24 | 2002-09-24 |  | 112.78d |  | start no earlier than 2002-06-24 | Irick [30%]; Nelson [30%]; Chranowski [30%] | 400h |
| 59 | 1.4.2.2 | **Develop SOW** |  | 25d | 2002-06-27 | 2002-07-31 |  | 109.44d |  |  |  | 60h |
| 60 | 1.4.2.2.1 | Review mfg studies, develop R&D statement of work |  | 25d | 2002-06-27 | 2002-07-31 |  | 109.44d | 0d | start no earlier than 2002-06-27 | Heitzenroeder [30%]; Nelson [10%] | 60h |
| 61 | 1.4.2.2.2 | Issue draft SOW for comment | milestone | 0d | 2002-07-31 | 2002-07-31 | 60 | 109.44d | 36.33d | start no earlier than 2002-07-03 |  |  |
| 62 | 1.4.2.3 | **Develop draft product spec and update Pro/E model** |  | 33.33d | 2002-08-06 | 2002-09-20 |  | 73.11d |  |  |  | 160h |
| 63 | 1.4.2.3.1 | Update casting portion of coil specification using CDR coilset |  | 33.33d | 2002-08-06 | 2002-09-20 |  | 73.11d | 0d | start no earlier than 2002-08-06 | Heitzenroeder [30%]; Nelson [30%] | 160h |
| 64 | 1.4.2.3.2 | Issue specification for comment | milestone | 0d | 2002-09-20 | 2002-09-20 | 63 | 73.11d | 0d | start no earlier than 2002-07-24 |  |  |
| 65 | 1.4.2.4 | **Develop RFP and selection criteria** |  | 39d | 2002-07-09 | 2002-08-30 |  | 91.44d |  |  |  | 112h |
| 66 | 1.4.2.4.1 | Resolve procurement strategy issues |  | 20d | 2002-07-09 | 2002-08-05 |  | 91.44d | 0d | finish no earlier than 2002-08-05 | Reiersen [10%]; Nelson [10%]; Heitzenroeder [10%] | 48h |
| 67 | 1.4.2.4.2 | Form SPEB |  | 10d | 2002-08-19 | 2002-08-30 | 66 | 129.44d |  | finish no earlier than 2002-08-30 | Reiersen [6.7%]; Nelson [6.7%]; Heitzenroeder [6.7%] | 16h |
| 68 | 1.4.2.4.3 | Develop selection criteria |  | 15d | 2002-08-06 | 2002-08-26 | 66 | 91.44d | 0d |  | Reiersen [13.3%]; Nelson [13.3%]; Heitzenroeder [13.3%] | 48h |
| 69 | 1.4.2.4.4 | Issue draft RFP for comment | milestone | 0d | 2002-08-26 | 2002-08-26 | 68 | 91.44d | 18.33d | start no earlier than 2002-08-19 |  |  |
| 70 | 1.4.2.5 | **Review, process, and approve contract documentation** |  | 2d | 2002-09-20 | 2002-09-24 | 61, 64, 69 | 73.11d |  |  | Nelson [30%]; Heitzenroeder [30%]; Reiersen [30%] | 14.4h |
| 71 | 1.4.2.5.1 | Clean up mfg web site, announce plans for modular coil procurement, contact suppliers who have previously expressed interest |  | 1d | 2002-09-20 | 2002-09-23 | 69 | 73.11d | 0d |  |  |  |
| 72 | 1.4.2.5.2 | Review procurement package including updated Pro/E model, draft spec, SOW, RFP, and selection criteria |  | 1d | 2002-09-23 | 2002-09-24 | 71 | 73.11d | 0d |  |  |  |
| 73 | 1.4.2.5.3 | Issue RFP via web | milestone | 0d | 2002-09-24 | 2002-09-24 | 72 | 73.11d | 0d | start no earlier than 2002-08-29 |  |  |
| 74 | 1.4.2.6 | Procure stereolithography models of latest configuration |  | 20d | 2002-08-20 | 2002-09-16 |  | 118.44d |  | start no earlier than 2002-08-20 | Williamson [12.5%] | 20h |
| 75 | 1.4.2.7 | **Suppliers develop proposals** |  | 30d | 2002-09-24 | 2002-11-05 |  | 83.11d |  |  |  | 100h |
| 76 | 1.4.2.7.1 | Conduct pre-proposal meeting with vendors | milestone | 0d | 2002-09-24 | 2002-09-24 | 73 | 96.44d | 0d | start no earlier than 2002-09-09 |  |  |
| 77 | 1.4.2.7.2 | Update package to include new coil geometry, vendor comments |  | 16.67d | 2002-09-24 | 2002-10-16 | 76 | 96.44d |  | start no earlier than 2002-09-11 | Nelson [30%]; Williamson [30%]; Heitzenroeder [30%]; Reiersen [30%] | 100h |
| 78 | 1.4.2.7.3 | Receive vendor proposals | milestone | 0d | 2002-11-05 | 2002-11-05 | 73FS+30d | 73.11d | 0d | start no earlier than 2002-09-18 |  |  |

| ID | WBS | Task | Type | Duration | Start | Finish | Predecessors | Total slack | Free slack | Constraint | Resources | Work |
| --- | --- | --- | --- | --- | --- | --- | --- | --- | --- | --- | --- | --- |
| 79 | 1.4.2.8 | **Award contracts** |  | 10d | 2002-11-05 | 2002-11-19 |  | 73.11d |  |  |  | 140h |
| 80 | 1.4.2.8.1 | Evaluate proposals, select and approve |  | 10d | 2002-11-05 | 2002-11-19 | 78 | 73.11d | 0d | start no earlier than 2002-09-20 | Nelson [50%]; Heitzenroeder [30%]; Reiersen | 140h |
| 81 | 1.4.2.8.2 | Issue contracts for modular coil R&D | milestone | 0d | 2002-11-19 | 2002-11-19 | 80 | 73.11d |  |  |  |  |
| 82 | 1.4.2.9 | **Initiate modular coil winding R&D activities** |  | 1d | 2002-06-17 | 2002-06-17 |  | 183.44d |  |  |  |  |
| 83 | 1.4.2.9.1 | Develop Winding R&D plans |  | 1d | 2002-06-17 | 2002-06-17 |  | 183.44d |  |  |  |  |
| 84 | 1.4.2.9.2 | Develop design criteria input requirements |  | 1d | 2002-06-17 | 2002-06-17 |  | 183.44d |  |  |  |  |
| 85 | 1.4.2.9.3 | Small coil fab/winding |  | 1d | 2002-06-17 | 2002-06-17 |  | 183.44d |  |  |  |  |
| 86 | 1.4.2.9.4 | Small Coil potting |  | 1d | 2002-06-17 | 2002-06-17 |  | 183.44d |  |  |  |  |
| 87 | 1.4.2.9.5 | Small coil testing |  | 1d | 2002-06-17 | 2002-06-17 |  | 183.44d |  |  |  |  |
| 88 | 1.4.2.9.6 | Winding mechanical properties available for design criteria |  | 1d | 2002-06-17 | 2002-06-17 |  | 183.44d |  |  |  |  |
| 89 | 1.4.2.9.7 | Winding Thermal properties available for design |  | 1d | 2002-06-17 | 2002-06-17 |  | 183.44d |  |  |  |  |
| 90 | 1.4.2.9.8 | Fatigue testing |  | 1d | 2002-06-17 | 2002-06-17 |  | 183.44d |  |  |  |  |
| 91 | 1.5 | **Structures** |  | 176d | 2002-06-24 | 2003-02-24 |  | 3.44d |  |  |  | 1100h |
| 92 | 1.5.1 | Optimize design of PF, TF, and structure in center stack |  | 75d | 2002-06-24 | 2002-10-04 |  | 37.78d | 7.33d | start no earlier than 2002-06-24 | Brown [30%]; Reiersen [20%] | 240h |
| 93 | 1.5.2 | Finalize design of crown structure, re segmentation |  | 33.33d | 2002-08-30 | 2002-10-16 |  | 30.44d | 0d | start no earlier than 2002-08-30 | Brown [30%]; Morris [30%] | 160h |
| 94 | 1.5.3 | Evaluate adjustability of base structure and revise |  | 33.33d | 2002-10-17 | 2002-12-03 |  | 63.11d |  | start no earlier than 2002-10-17 | Brown [30%]; Rushinski [30%] | 160h |
| 95 | 1.5.4 | Develop TF radial positioning function |  | 50d | 2002-06-24 | 2002-08-30 |  | 129.44d |  | start no earlier than 2002-06-24 | Brown [30%]; Morris [30%] | 200h |
| 96 | 1.5.5 | Lighten structure, add draft features as required |  | 25d | 2002-12-04 | 2003-01-07 |  | 37.44d |  | start no earlier than 2002-12-04 | Brown [30%] | 60h |
| 97 | 1.5.6 | Analyze time constants, electrical break requirements in structure |  | 25d | 2003-01-21 | 2003-02-24 | 92, 93 | 3.44d |  | start no earlier than 2003-01-21 | Brooks [50%] | 100h |
| 98 | 1.5.7 | Update stress analysis of PF/TF and coil support structure |  | 66.67d | 2002-10-16 | 2003-01-16 | 92, 93 | 30.44d |  |  | Fan [50%]; Jun [15%] | 180h |
| 99 | 1.6 | **Cryostat** |  | 25d | 2002-06-24 | 2002-07-26 |  | 154.44d |  |  |  | 40h |
| 100 | 1.6.1 | Investigate options to reduce flammability |  | 25d | 2002-06-24 | 2002-07-26 |  | 154.44d |  | start no earlier than 2002-06-24 | Goranson [20%] | 40h |
| 101 | 1.7 | **Coil Services** |  | 33.67d | 2002-09-03 | 2002-10-18 |  | 94.78d |  |  |  | 80h |
| 102 | 1.7.1 | Evaluate stability of LN2 flow distribution concept |  | 16.67d | 2002-09-26 | 2002-10-18 |  | 94.78d |  | start no earlier than 2002-09-26 | Dahlgren [30%] | 40h |
| 103 | 1.7.2 | Evaluate cooling requirements for coil lead concept |  | 16.67d | 2002-09-03 | 2002-09-25 | 47 | 111.78d |  | start no earlier than 2002-09-03 | Dahlgren [30%] | 40h |

| ID | WBS | Task | Duration | Start | Finish | Total slack | Constraint | Resources | Work |
| --- | --- | --- | --- | --- | --- | --- | --- | --- | --- |
| 104 | 1.8 | **Field Period Assembly** | 100d | 2002-06-24 | 2002-11-08 | 79.44d |  |  | 160h |
| 105 | 1.8.1 | Re-evaluate coil-vessel assembly sequence | 100d | 2002-06-24 | 2002-11-08 | 79.44d | start no earlier than 2002-06-24 | Chranowski [20%] | 160h |
| 106 | 1.9 | **Stellarator Core Integration** | 184.44d | 2002-06-17 | 2003-02-28 | 0d |  |  | 480h |
| 107 | 1.9.1 | Develop scope of coil protection system, incl failure mode / fault analysis | 44.44d | 2002-12-30 | 2003-02-28 | 0d | start no earlier than 2002-12-28 | Nelson [30%]; Ramakrishnan [15%] | 160h |
| 108 | 1.9.2 | Develop solutions for key diagnostics, incl x-ray tomography | 37.5d | 2002-06-24 | 2002-08-14 | 141.94d | start no earlier than 2002-06-24 | Cole [40%] | 120h |
| 109 | 1.9.3 | Perform systematic coil tolerance study, including relationship of field errors to geometry errors | 1d | 2002-06-17 | 2002-06-17 | 183.44d |  |  |  |
| 110 | 1.9.4 | Generate drawing tree, document lists, and design review schedule | 40d | 2002-09-10 | 2002-11-04 | 83.44d | start no earlier than 2002-09-10 | Cole [50%]; Brown [30%] | 200h |
